# Schedule

Schedule from MS Project, 2011-03-15 to 2012-09-25.
MBARI

## Calendars

- Standard: Mon-Fri 08:00-12:00, 13:00-17:00; Sat-Sun off.

## Schedule

| ID | WBS | Task | Duration | Start | Finish | Predecessors | Total slack | Free slack | Constraint |
| --- | --- | --- | --- | --- | --- | --- | --- | --- | --- |
| 3 | 1 | Electrical Gen. at-sea test | 40d? | 2011-11-14 | 2012-01-06 |  | 187d |  | start no earlier than 2011-11-14 |
| 6 | 2 | Power Converter Design, build and test | 208d? | 2011-06-01 | 2012-03-16 |  | 127d | 95d | finish no earlier than 2012-03-16 |
| 7 | 3 | Preliminary Design | 128d? | 2011-06-01 | 2011-11-25 |  | 217d |  | finish no earlier than 2011-11-25 |
| 8 | 4 | Component Fabrication | 25d? | 2011-11-28 | 2011-12-30 |  | 192d |  | finish no earlier than 2011-12-30 |
| 9 | 5 | Lab Testing | 25d? | 2012-01-02 | 2012-02-03 |  | 167d |  | finish no earlier than 2012-02-03 |
| 10 | 6 | Integration for at-sea use | 24d? | 2012-02-06 | 2012-03-08 |  | 143d |  | finish no earlier than 2012-03-08 |
| 11 | 7 | Battery Charge Test at Sea | 5d? | 2012-03-12 | 2012-03-16 |  | 137d |  | finish no earlier than 2012-03-16 |
| 14 | 8 | Power Passthru Wiring Integration | 176d? | 2011-06-01 | 2012-02-01 |  | 164d | 42d | start no earlier than 2011-06-01 |
| 18 | 9 | AUV Homing Tests | 140d? | 2011-05-02 | 2011-11-11 |  | 222d | 100d | start no earlier than 2011-05-02 |
| 21 | 10 | AUV Dock Design and Fabrication | 253d? | 2011-03-15 | 2012-03-01 |  | 148d |  | start no earlier than 2011-03-15 |
| 22 | 11 | Concept Development | 57d? | 2011-03-15 | 2011-06-01 |  | 83d | 0d | start no earlier than 2011-03-15 |
| 23 | 12 | Concept Design Review | 1d? | 2011-06-02 | 2011-06-02 | 22 | 83d | 0d |  |
| 24 | 13 | Design work | 92d? | 2011-06-03 | 2011-10-10 | 23 | 83d | 0d | start no earlier than 2011-06-03 |
| 25 | 14 | Prelimiminary Design Review | 1d? | 2011-10-11 | 2011-10-11 | 24 | 83d | 0d | start no earlier than 2011-10-11 |
| 26 | 15 | Detailed Design Work | 61d? | 2011-10-12 | 2012-01-04 | 25 | 83d | 0d | finish no earlier than 2012-01-04 |
| 27 | 16 | Critical Design Review | 1d? | 2012-01-05 | 2012-01-05 | 26 | 83d | 0d |  |
| 28 | 17 | Dock Fabrication | 40d? | 2012-01-06 | 2012-03-01 | 27 | 83d | 0d | finish no earlier than 2012-01-31 |
| 29 | 18 | Lab Integration and Test | 21d? | 2012-03-02 | 2012-03-30 | 28 | 83d | 0d | start no earlier than 2012-02-01 |
| 32 | 19 | Dock Test on Stationary Mooring | 44d? | 2012-04-02 | 2012-05-31 | 29 | 83d |  | finish no earlier than 2012-05-31 |
| 33 | 20 | Dock Deployment | 5d? | 2012-04-02 | 2012-04-06 | 18, 14 | 122d |  | finish no earlier than 2012-04-06 |
| 34 | 21 | AUV Dock Testing | 39d? | 2012-04-09 | 2012-05-31 |  | 73d | 21d | finish no earlier than 2012-05-31 |
| 36 | 22 | AUV Dock test to wave-energy buoy | 10d? | 2012-07-02 | 2012-07-13 | 34 | 52d |  | finish no earlier than 2012-07-13 |
| 37 | 23 | Wave-Energy buoy deployment with Dock | 1d? | 2012-07-02 | 2012-07-02 |  | 61d |  | start no earlier than 2012-07-02 |
| 38 | 24 | AUV Dock Testing | 8d? | 2012-07-04 | 2012-07-13 |  | 52d |  | finish no earlier than 2012-07-13 |
| 40 | 25 | Propulsion Testing | 55d? | 2012-04-02 | 2012-06-15 |  | 72d |  | finish no earlier than 2012-06-15 |
| 41 | 26 | System Design and Component Selection | 15d? | 2012-04-02 | 2012-04-23 |  | 112d |  | finish no earlier than 2012-04-23 |
| 42 | 27 | Fabrication | 15d? | 2012-04-23 | 2012-05-11 |  | 97d |  | start no earlier than 2012-04-23 |
| 43 | 28 | Integration and Test | 14d? | 2012-05-14 | 2012-05-31 |  | 83d |  | start no earlier than 2012-05-14 |
| 44 | 29 | Test Deployment | 11d? | 2012-06-01 | 2012-06-15 |  | 72d |  | start no earlier than 2012-05-31 |
| 46 | 30 | Two-Week Demonstration Deployment | 10d? | 2012-07-30 | 2012-08-10 | 6 | 32d |  | start no earlier than 2012-07-30 |
| 49 | 31 | Final Report Writing | 22d? | 2012-08-27 | 2012-09-25 |  | 0d |  | finish no earlier than 2012-09-25 |
